Schedule from MS Project, 2025-06-15 to 2026-11-09.
Microsoft

## Calendars

- Стандартный: Mon-Sun 09:00-13:00, 14:00-18:00.

## Schedule

| ID | WBS | Task | Duration | Start | Finish | Total slack | Constraint |
| --- | --- | --- | --- | --- | --- | --- | --- |
| 1 | 1 | **Электрика** | 513d | 2025-06-15 | 2026-11-09 | 0d |  |
| 2 | 1.1 | Внутриплощадочные сети электроснабжения. Система бесперебойного гарантированного электроснабжения 1632-2021-00-ЭС1.СУБ | 70d | 2025-09-18 | 2025-11-26 | 348d | start no earlier than 2025-09-18 |
| 3 | 1.2 | Станция разгрузки вагонов. Трансбордер. Тоннель. Силовое электрооборудование. Электрическое освещение (внутреннее) 1632-2021-1.1, 1.2, 2.1.0-ЭОМ | 30d | 2025-08-31 | 2025-09-29 | 406d | start no earlier than 2025-08-31 |
| 4 | 1.3 | Конвейерная галерея №1. Силовое электрооборудование. Электрическое освещение (внутреннее) 1632-2021-2.1.1-ЭОМ | 35d | 2025-08-28 | 2025-10-01 | 404d | start no earlier than 2025-08-28 |
| 5 | 1.4 | Конвейерная галерея №2 и конвейерная галерея №7. Силовое электрооборудование. Электрическое освещение (внутреннее) в осях 1-7 1632-2021-2.1.2, 2.1.7-ЭОМ1 | 33d | 2025-12-10 | 2026-01-11 | 302d | start no earlier than 2025-12-10 |
| 6 | 1.5 | Конвейерная галерея №2 и конвейерная галерея №7. Силовое электрооборудование. Электрическое освещение (внутреннее) в осях 8-14 1632-2021-2.1.2, 2.1.7-ЭОМ2 | 38d | 2025-12-13 | 2026-01-19 | 294d | start no earlier than 2025-12-13 |
| 7 | 1.6 | Конвейерная галерея №2 и конвейерная галерея №7. Силовое электрооборудование. Электрическое освещение (внутреннее) в осях 15-23 1632-2021-2.1.2, 2.1.7-ЭОМ3 | 41d | 2025-12-13 | 2026-01-22 | 291d | start no earlier than 2025-12-13 |
| 8 | 1.7 | Конвейерная галерея №3. Силовое электрооборудование. Электрическое освещение (внутреннее) 1632-2021-2.1.3-ЭОМ | 40d | 2025-10-29 | 2025-12-07 | 337d | start no earlier than 2025-10-29 |
| 9 | 1.8 | Конвейерная галерея №4. Силовое электрооборудование. Электрическое освещение (внутреннее) 1632-2021-2.1.4-ЭОМ | 36d | 2025-06-15 | 2025-07-20 | 477d | start no earlier than 2025-06-15 |
| 10 | 1.9 | Конвейерная галерея №5. Силовое электрооборудование. Электрическое освещение (внутреннее) 1632-2021-2.1.5-ЭОМ | 36d | 2025-10-04 | 2025-11-08 | 366d | start no earlier than 2025-10-04 |
| 11 | 1.10 | Конвейерная галерея №11. Силовое электрооборудование. Электрическое освещение (внутреннее) 1632-2021-2.1.11-ЭОМ | 40d | 2026-03-02 | 2026-04-10 | 213d | start no earlier than 2026-03-02 |
| 12 | 1.11 | Конвейерная галерея №12. Силовое электрооборудование. Электрическое освещение (внутреннее) 1632-2021-2.1.12-ЭОМ | 40d | 2026-03-02 | 2026-04-10 | 213d | start no earlier than 2026-03-02 |
| 13 | 1.12 | Пересыпная станция № 1. Силовое электрооборудование. Электрическое освещение (внутреннее) 1632-2021-2.2.1-ЭОМ | 70d | 2025-08-31 | 2025-11-08 | 366d | start no earlier than 2025-08-31 |
| 14 | 1.13 | Пересыпная станция № 2. Силовое электрооборудование. Электрическое освещение (внутреннее) 1632-2021-2.2.2-ЭОМ | 70d | 2025-08-31 | 2025-11-08 | 366d | start no earlier than 2025-08-31 |
| 15 | 1.14 | Пересыпная станция № 3. Силовое электрооборудование. Электрическое освещение (внутреннее) 1632-2021-2.2.3-ЭОМ | 61d | 2025-08-20 | 2025-10-19 | 386d | start no earlier than 2025-08-20 |
| 16 | 1.15 | Пересыпная станция №4, конвейерная галерея №6. Силовое электрооборудование. Электрическое освещение (внутреннее) 1632-2021-2.2.4, 2.1.6-ЭОМ | 56d | 2025-10-28 | 2025-12-22 | 322d | start no earlier than 2025-10-28 |
| 17 | 1.16 | Пересыпная станция №5. Силовое электрооборудование. Электрическое освещение (внутреннее) 1632-2021-2.2.5-ЭОМ | 55d | 2025-12-09 | 2026-02-01 | 281d | start no earlier than 2025-12-09 |
| 18 | 1.17 | Пересыпная станция №6. Силовое электрооборудование. Электрическое освещение (внутреннее) 1632-2021-2.2.6-ЭОМ | 40d | 2026-04-01 | 2026-05-10 | 183d | start no earlier than 2026-04-01 |
| 19 | 1.18 | Приводная станция. Силовое электрооборудование. Электрическое освещение (внутреннее) 1632-2021-2.2.7-ЭОМ | 40d | 2025-07-30 | 2025-09-07 | 428d | start no earlier than 2025-07-30 |
| 20 | 1.19 | Крытый склад № 1. Силовое оборудование. Электрическое освещение (внутреннее) 1632-2021-3.1-ЭОМ | 35d | 2026-01-06 | 2026-02-09 | 273d | start no earlier than 2026-01-06 |
| 21 | 1.20 | Крытый склад № 1. Система электрического обогрева водостоков 1632-2021-3.1-СЭО | 35d | 2026-01-06 | 2026-02-09 | 273d | start no earlier than 2026-01-06 |
| 22 | 1.21 | Крытый склад № 2. Силовое оборудование. Электрическое освещение (внутреннее) 1632-2021-3.2-ЭОМ | 87d | 2026-08-15 | 2026-11-09 | 0d | start no earlier than 2026-08-15 |
| 23 | 1.22 | Ангар для хранения ТМЦ. Силовое электрооборудование. Электрическое освещение (внутреннее) 1632-2021-3.4-ЭОМ | 30d | 2025-11-24 | 2025-12-23 | 321d | start no earlier than 2025-11-24 |
| 24 | 1.23 | Здание КПП со спецпроходной. Силовое электрооборудование. Электрическое освещение (внутреннее) 1632-2021-8.4-ЭОМ | 39d | 2025-09-18 | 2025-10-26 | 379d | start no earlier than 2025-09-18 |
