Schedule from MS Project, 2025-06-15 to 2026-11-09.
Microsoft

## Calendars

- Стандартный: Mon-Sun 09:00-13:00, 14:00-18:00.

## Schedule

| ID | WBS | Task | Duration | Start | Finish | Total slack | Constraint |
| --- | --- | --- | --- | --- | --- | --- | --- |
| 1 | 1 | **Электрика** | 512.88d? | 2025-06-15 | 2026-11-09 | 0d |  |
| 2 | 1.1 | Внутриплощадочные сети электроснабжения. Система бесперебойного гарантированного электроснабжения 1632-2021-00-ЭС1.СУБ | 69.88d? | 2025-09-18 | 2025-11-26 | 348d | finish no earlier than 2025-11-26 |
| 3 | 1.2 | Станция разгрузки вагонов. Трансбордер. Тоннель. Силовое электрооборудование. Электрическое освещение (внутреннее) 1632-2021-1.1, 1.2, 2.1.0-ЭОМ | 29.88d? | 2025-08-31 | 2025-09-29 | 406d | finish no earlier than 2025-09-29 |
| 4 | 1.3 | Конвейерная галерея №1. Силовое электрооборудование. Электрическое освещение (внутреннее) 1632-2021-2.1.1-ЭОМ | 34.88d? | 2025-08-28 | 2025-10-01 | 404d | finish no earlier than 2025-10-01 |
| 5 | 1.4 | Конвейерная галерея №2 и конвейерная галерея №7. Силовое электрооборудование. Электрическое освещение (внутреннее) в осях 1-7 1632-2021-2.1.2, 2.1.7-ЭОМ1 | 32.88d? | 2025-12-10 | 2026-01-11 | 302d | finish no earlier than 2026-01-11 |
| 6 | 1.5 | Конвейерная галерея №2 и конвейерная галерея №7. Силовое электрооборудование. Электрическое освещение (внутреннее) в осях 8-14 1632-2021-2.1.2, 2.1.7-ЭОМ2 | 37.88d? | 2025-12-13 | 2026-01-19 | 294d | finish no earlier than 2026-01-19 |
| 7 | 1.6 | Конвейерная галерея №2 и конвейерная галерея №7. Силовое электрооборудование. Электрическое освещение (внутреннее) в осях 15-23 1632-2021-2.1.2, 2.1.7-ЭОМ3 | 40.88d? | 2025-12-13 | 2026-01-22 | 291d | finish no earlier than 2026-01-22 |
| 8 | 1.7 | Конвейерная галерея №3. Силовое электрооборудование. Электрическое освещение (внутреннее) 1632-2021-2.1.3-ЭОМ | 39.88d? | 2025-10-29 | 2025-12-07 | 337d | finish no earlier than 2025-12-07 |
| 9 | 1.8 | Конвейерная галерея №4. Силовое электрооборудование. Электрическое освещение (внутреннее) 1632-2021-2.1.4-ЭОМ | 26.88d? | 2025-06-15 | 2025-07-11 | 486d | finish no earlier than 2025-07-11 |
| 10 | 1.9 | Конвейерная галерея №5. Силовое электрооборудование. Электрическое освещение (внутреннее) 1632-2021-2.1.5-ЭОМ | 22.88d? | 2025-10-04 | 2025-10-26 | 379d | finish no earlier than 2025-10-26 |
| 11 | 1.10 | Конвейерная галерея №11. Силовое электрооборудование. Электрическое освещение (внутреннее) 1632-2021-2.1.11-ЭОМ | 23.88d? | 2026-03-02 | 2026-03-25 | 229d | finish no earlier than 2026-03-25 |
| 12 | 1.11 | Конвейерная галерея №12. Силовое электрооборудование. Электрическое освещение (внутреннее) 1632-2021-2.1.12-ЭОМ | 23.88d? | 2026-03-02 | 2026-03-25 | 229d | finish no earlier than 2026-03-25 |
| 13 | 1.12 | Пересыпная станция № 1. Силовое электрооборудование. Электрическое освещение (внутреннее) 1632-2021-2.2.1-ЭОМ | 69.88d? | 2025-08-31 | 2025-11-08 | 366d | finish no earlier than 2025-11-08 |
| 14 | 1.13 | Пересыпная станция № 2. Силовое электрооборудование. Электрическое освещение (внутреннее) 1632-2021-2.2.2-ЭОМ | 69.88d? | 2025-08-31 | 2025-11-08 | 366d | finish no earlier than 2025-11-08 |
| 15 | 1.14 | Пересыпная станция № 3. Силовое электрооборудование. Электрическое освещение (внутреннее) 1632-2021-2.2.3-ЭОМ | 60.88d? | 2025-08-20 | 2025-10-19 | 386d | finish no earlier than 2025-10-19 |
| 16 | 1.15 | Пересыпная станция №4, конвейерная галерея №6. Силовое электрооборудование. Электрическое освещение (внутреннее) 1632-2021-2.2.4, 2.1.6-ЭОМ | 55.88d? | 2025-10-28 | 2025-12-22 | 322d | finish no earlier than 2025-12-22 |
| 17 | 1.16 | Пересыпная станция №5. Силовое электрооборудование. Электрическое освещение (внутреннее) 1632-2021-2.2.5-ЭОМ | 54.88d? | 2025-12-09 | 2026-02-01 | 281d | finish no earlier than 2026-02-01 |
| 18 | 1.17 | Пересыпная станция №6. Силовое электрооборудование. Электрическое освещение (внутреннее) 1632-2021-2.2.6-ЭОМ | 27.88d? | 2026-04-01 | 2026-04-28 | 195d | finish no earlier than 2026-04-28 |
| 19 | 1.18 | Приводная станция. Силовое электрооборудование. Электрическое освещение (внутреннее) 1632-2021-2.2.7-ЭОМ | 34.88d? | 2025-07-30 | 2025-09-02 | 433d | finish no earlier than 2025-09-02 |
| 20 | 1.19 | Крытый склад № 1. Силовое оборудование. Электрическое освещение (внутреннее) 1632-2021-3.1-ЭОМ | 19.88d? | 2026-01-06 | 2026-01-25 | 288d | finish no earlier than 2026-01-25 |
| 21 | 1.20 | Крытый склад № 1. Система электрического обогрева водостоков 1632-2021-3.1-СЭО | 19.88d? | 2026-01-06 | 2026-01-25 | 288d | finish no earlier than 2026-01-25 |
| 22 | 1.21 | Крытый склад № 2. Силовое оборудование. Электрическое освещение (внутреннее) 1632-2021-3.2-ЭОМ | 86.88d? | 2026-08-15 | 2026-11-09 | 0d | finish no earlier than 2026-11-09 |
| 23 | 1.22 | Ангар для хранения ТМЦ. Силовое электрооборудование. Электрическое освещение (внутреннее) 1632-2021-3.4-ЭОМ | 27.88d? | 2025-11-24 | 2025-12-21 | 323d | finish no earlier than 2025-12-21 |
| 24 | 1.23 | Здание КПП со спецпроходной. Силовое электрооборудование. Электрическое освещение (внутреннее) 1632-2021-8.4-ЭОМ | 38.88d? | 2025-09-18 | 2025-10-26 | 379d | finish no earlier than 2025-10-26 |
